# Programa Anual de Mantenimientos del SEN 2017modificado

Schedule from MS Project, 2017-01-09 to 2018-12-31, 10 hours a day.

## Calendars

- 24 horas: Mon-Sun 00:00-24:00.

## Resources

| Resource |
| --- |
| 01:06 |
| 08:36 |
| 10:45 |
| 01:38 |
| 20:05 |
| 11:26 |
| 01:57 |
| 04:14 |
| 03:36 |
| 18:16 |
| 23:00 |
| 00:01 |
| 10:40 |
| 12:00 |
| 18:20 |
| 11:40 |
| 16:24 |
| 20:35 |
| 14:00 |
| 10:53 |
| 10:26 |
| 18:42 |
| 18:23 |
| 18:51 |
| 01:40 |
| 02:00 |
| 00:52 |
| 04:35 |
| 15:42 |
| 21:00 |
| 18:36 |
| 16:00 |
| 23:59 |
| 09:47 |
| 00:41 |
| 03:59 |
| 16:43 |
| 20:00 |
| 16:50 |
| 10:32 |
| 12:04 |
| 09:00 |
| 06:00 |
| 18:00 |
| 17:31 |
| 16:54 |
| 17:00 |
| 08:38 |
| 18:45 |
| 10:47 |
| 09:43 |
| 00:36 |
| 02:07 |
| 03:34 |
| 03:31 |
| 11:20 |
| 17:21 |
| 01:34 |
| 02:55 |
| 08:53 |
| 16:45 |
| 16:38 |
| 14:32 |
| 01:14 |
| 03:00 |
| 04:06 |
| 00:00 |
| 09:23 |
| 16:57 |
| 13:28 |
| 11:00 |
| 15:00 |
| 17:01 |
| 10:33 |
| 04:00 |
| 11:05 |
| 11:32 |
| 01:53 |
| 01:58 |
| 05:00 |
| 04:38 |
| 19:31 |
| 01:36 |
| 08:47 |
| 02:27 |
| 01:43 |
| 01:50 |
| 19:08 |
| 16:27 |
| 09:34 |
| 00:44 |
| 01:30 |
| 10:46 |
| 14:50 |
| 00:08 |
| 14:13 |
| 14:08 |
| 14:11 |
| 23:18 |
| 22:40 |
| 01:16 |
| 01:23 |
| 04:45 |
| 10:00 |
| 01:47 |
| 18:09 |
| 09:38 |
| 18:34 |
| 19:13 |
| 21:18 |
| 04:48 |
| 11:30 |
| 08:00 |
| 22:00 |
| 07:00 |

## Schedule

| ID | Task | Type | Duration | Start | Finish | Hora inicio | Unidad | Potencia indisponible | Text11 | Text12 | Text13 | Text14 | Consecutivo |
| --- | --- | --- | --- | --- | --- | --- | --- | --- | --- | --- | --- | --- | --- |
| 1 | PH Garita | manual | 18.8d | 2017-01-14 | 2017-01-21 | 04:00 | Unidad 1 | 20 | Alex Soto Jimenez | 20003426 | 20003417 | 20 |  |
| 2 | PH Garita | manual | 8.9d | 2017-06-02 | 2017-06-05 | 04:00 | Unidad 1 | 20 | Alex Soto Jimenez | 20003426 | 20003417 | 20 |  |
| 3 | PH Garita | manual | 9.2d | 2017-11-17 | 2017-11-20 | 04:00 | Unidad 1 | 20 | Alex Soto Jimenez | 20003426 | 20003417 | 20 |  |
| 4 | PH Garita | manual | 18.8d | 2017-01-23 | 2017-01-30 | 04:00 | Unidad 2 | 20 | Alex Soto Jimenez | 20003426 | 20003417 | 20 |  |
| 5 | PH Garita | manual | 8.9d | 2017-06-02 | 2017-06-05 | 04:00 | Unidad 2 | 20 | Alex Soto Jimenez | 20003426 | 20003417 | 20 |  |
| 6 | PH Garita | manual | 9.2d | 2017-11-17 | 2017-11-20 | 04:00 | Unidad 2 | 20 | Alex Soto Jimenez | 20003426 | 20003417 | 20 |  |
| 7 | PH Ventanas Garita | manual | 112.8d | 2017-01-30 | 2017-03-17 | 06:00 | Unidad 1 | 50 | Alex Soto Jimenez | 20003426 | 20003417 | 50 |  |
| 8 | PH Ventanas Garita | manual | 19d | 2017-04-21 | 2017-04-28 | 02:00 | Unidad 1 | 50 | Alex Soto Jimenez | 20003426 | 20003417 | 50 |  |
| 9 | PH Ventanas Garita | manual | 9.4d | 2017-12-01 | 2017-12-04 | 02:00 | Unidad 1 | 50 | Alex Soto Jimenez | 20003426 | 20003417 | 50 |  |
| 10 | PH Ventanas Garita | manual | 40.2d | 2017-03-22 | 2017-04-07 | 06:00 | Unidad 2 | 50 | Alex Soto Jimenez | 20003426 | 20003417 | 50 | 10 |
| 11 | PH Ventanas Garita | manual | 19d | 2017-04-21 | 2017-04-28 | 02:00 | Unidad 2 | 50 | Alex Soto Jimenez | 20003426 | 20003417 | 50 | 11 |
| 12 | PH Ventanas Garita | manual | 9.4d | 2017-12-01 | 2017-12-04 | 02:00 | Unidad 2 | 50 | Alex Soto Jimenez | 20003426 | 20003417 | 50 | 12 |
| 13 | PH Echandi | manual | 28.4d | 2017-06-12 | 2017-06-23 | 04:00 | Unidad 1 | 4.2 | Alex Soto Jimenez | 20003426 | 20003417 | 4.3 | 13 |
| 14 | PH Toro I | manual | 74.7d | 2017-05-18 | 2017-06-18 | 21:00 | Unidad 1 | 12 | Luis Alfredo Mora | 20003638 | 87065058 | 12.70 | 14 |
| 15 | PH Toro I | manual | 7.5d | 2017-05-18 | 2017-05-21 | 21:00 | Unidad 2 | 12 | Luis Alfredo Mora | 20003638 | 87065058 | 12.70 | 15 |
| 16 | PH Toro I | manual | 7.5d | 2017-06-08 | 2017-06-11 | 21:00 | Unidad 2 | 12 | Luis Alfredo Mora | 20003638 | 87065058 | 12.70 | 16 |
| 17 | PH Toro I | manual | 49.9d | 2017-03-20 | 2017-04-09 | 05:00 | Unidad 2 | 12 | Luis Alfredo Mora | 20003638 | 87065058 | 12.70 | 17 |
| 18 | PH Toro II | manual | 33.1d | 2017-05-01 | 2017-05-14 | 05:00 | Unidad 1 | 33 | Luis Alfredo Mora | 20003638 | 87065058 | 33.00 | 18 |
| 19 | PH Toro II | manual | 49.9d | 2017-02-20 | 2017-03-12 | 05:00 | Unidad 2 | 33 | Luis Alfredo Mora | 20003638 | 87065058 | 33.00 | 19 |
| 20 | PH Toro II | manual | 7.5d | 2017-05-18 | 2017-05-21 | 21:00 | Unidad 1 | 33 | Luis Alfredo Mora | 20003638 | 87065058 | 66.00 | 20 |
| 21 | PH Toro II | manual | 7.5d | 2017-06-08 | 2017-06-11 | 21:00 | Unidad 1 | 33 | Luis Alfredo Mora | 20003638 | 87065058 | 66.00 | 21 |
| 22 | PH Toro II | manual | 8.9d | 2017-10-27 | 2017-10-30 | 07:00 | Unidad 1 | 33 | Luis Alfredo Mora | 20003638 | 87065058 | 66.00 | 22 |
| 23 | PH Toro III | manual | 33.1d | 2017-04-24 | 2017-05-07 | 05:00 | Unidad 1 | 24 | J. Manuel Rodríguez | 20002305 | 89223534 | 23.76 | 23 |
| 24 | PH Toro III | manual | 49.9d | 2017-02-20 | 2017-03-12 | 05:00 | Unidad 2 | 24 | J. Manuel Rodríguez | 20002305 | 89223534 | 23.76 | 24 |
| 25 | PH Toro III | manual | 7.5d | 2017-05-18 | 2017-05-21 | 21:00 | Unidad 1 | 24 | Luis Alfredo Mora | 20003638 | 87065058 | 47.52 | 25 |
| 26 | PH Toro III | manual | 7.5d | 2017-06-08 | 2017-06-11 | 21:00 | Unidad 1 | 24 | J. Manuel Rodríguez | 20002305 | 89223534 | 47.52 | 26 |
| 27 | PH Toro III | manual | 8.9d | 2017-10-27 | 2017-10-30 | 07:00 | Unidad 1 | 24 | J. Manuel Rodríguez | 20002305 | 89223534 | 47.52 | 27 |
| 28 | PH Peñas Blancas | manual | 31.2d | 2017-02-27 | 2017-03-12 | 00:00 | Unidad 1 | 18 | Rolando Solís Durán | 20003751 | 88249276 | 18.00 | 28 |
| 29 | PH Peñas Blancas | manual | 31.2d | 2017-03-20 | 2017-04-02 | 00:00 | Unidad 2 | 18 | Rolando Solís Durán | 20003751 | 88249276 | 18.00 | 29 |
| 30 | PH Peñas Blancas | manual | 7.2d | 2017-09-07 | 2017-09-10 | 00:00 | Unidad 1 | 18 | Rolando Solís Durán | 20003751 | 88249276 | 36.00 | 30 |
| 31 | PH Peñas Blancas | manual | 7.2d | 2017-10-19 | 2017-10-22 | 00:00 | Unidad 1 | 18 | Rolando Solís Durán | 20003751 | 88249276 | 36.00 | 31 |
| 32 | PH Peñas Blancas | manual | 8d | 2017-11-16 | 2017-11-19 | 08:00 | Unidad 1 | 18 | Rolando Solís Durán | 20003751 | 88249276 | 36.00 | 32 |
| 33 | PH Cariblanco | manual | 16.8d | 2017-02-13 | 2017-02-19 | 00:00 | Unidad 1 | 41 | Javier Chacón S. | 20003725 | 88899717 | 41.00 | 33 |
| 34 | PH Cariblanco | manual | 16.8d | 2017-02-20 | 2017-02-26 | 00:00 | Unidad 2 | 41 | Javier Chacón S. | 20003725 | 88899717 | 41.00 | 34 |
| 35 | PH Cariblanco | manual | 2.4d | 2017-11-17 | 2017-11-18 | 00:00 | Unidad 1 | 41 | Javier Chacón S. | 20003725 | 88899717 | 82.00 | 35 |
| 36 | PH Cariblanco | manual | 4.8d | 2017-09-29 | 2017-10-01 | 00:00 | Unidad 1 | 41 | Javier Chacón S. | 20003725 | 88899717 | 82.00 | 36 |
| 37 | PH Cariblanco | manual | 6d | 2017-06-27 | 2017-06-29 | 00:00 | Unidad 2 | 41 | Javier Chacón S. | 20003725 | 88899717 | 41.00 | 37 |
| 38 | PT San Antonio | manual | 27.3d | 2017-07-31 | 2017-08-11 | 07:00 | Unidad 1 | 18 | Dennis López Hernández | 25011227 | 88658533 | 18.38 | 38 |
| 39 | PT San Antonio | manual | 27.3d | 2017-08-21 | 2017-09-01 | 07:00 | Unidad 2 | 18 | Dennis López Hernández | 25011227 | 88658533 | 18.38 | 39 |
| 40 | PT San Antonio | manual | 5.7d | 2017-09-11 | 2017-09-13 | 07:00 | Unidad 1 | 18 | Dennis López Hernández | 25011227 | 88658533 | 18.38 | 40 |
| 41 | PT San Antonio | manual | 5.7d | 2017-09-11 | 2017-09-13 | 07:00 | Unidad 2 | 18 | Dennis López Hernández | 25011227 | 88658533 | 18.38 | 41 |
| 42 | PT Guápiles | manual | 10.4d | 2017-01-09 | 2017-01-13 | 07:00 | Unidad 1 | 6.8 | Jefrey Chaves Coto | 20002701 | 83835821 | 6.82 | 42 |
| 43 | PT Guápiles | manual | 10.4d | 2017-01-16 | 2017-01-20 | 07:00 | Unidad 2 | 6.8 | Jefrey Chaves Coto | 20002701 | 83835821 | 6.82 | 43 |
| 44 | PT Guápiles | manual | 15.2d | 2017-07-17 | 2017-07-23 | 07:00 | Unidad 1 | 6.8 | Jefrey Chaves Coto | 20002701 | 83835821 | 6.82 | 44 |
| 45 | PT Guápiles | manual | 15.2d | 2017-07-17 | 2017-07-23 | 07:00 | Unidad 2 | 6.8 | Jefrey Chaves Coto | 20002701 | 83835821 | 6.82 | 45 |
| 46 | PT Guápiles | manual | 12.8d | 2017-08-07 | 2017-08-12 | 07:00 | Unidad 2 | 6.8 | Jefrey Chaves Coto | 20002701 | 83835821 | 6.82 | 46 |
| 47 | PT Guápiles | manual | 3.4d | 2017-12-04 | 2017-12-05 | 07:00 | Unidad 1 | 6.8 | Jefrey Chaves Coto | 20002701 | 83835821 | 6.82 | 47 |
| 48 | PT Guápiles | manual | 3.4d | 2017-12-06 | 2017-12-07 | 07:00 | Unidad 2 | 6.8 | Jefrey Chaves Coto | 20002701 | 83835821 | 6.82 | 48 |
| 49 | PH Pirrís | manual | 3.8d | 2017-01-16 | 2017-01-17 | 06:00 | Unidad 1 | 70 | Deiby Arias O | 25011106 | 25011127 | 70.00 | 49 |
| 50 | PH Pirrís | manual | 38h | 2017-01-18 | 2017-01-19 | 06:00 | Unidad 2 | 70 | Deiby Arias O | 25011106 | 25011127 | 70.00 | 50 |
| 51 | PH Pirrís | manual | 38h | 2017-04-08 | 2017-04-09 | 06:00 | Unidad 1 | 70 | Deiby Arias O | 25011106 | 25011127 | 70.00 | 51 |
| 52 | PH Pirrís | manual | 38h | 2017-04-15 | 2017-04-16 | 06:00 | Unidad 2 | 70 | Deiby Arias O | 25011106 | 25011127 | 70.00 | 52 |
| 53 | PH Pirrís | manual | 16.8d | 2017-07-19 | 2017-07-25 | 00:00 | Unidad 2 | 70 | Deiby Arias O | 25011106 | 25011127 | 70.00 | 53 |
| 54 | PH Pirrís | manual | 25.8d | 2017-07-07 | 2017-07-17 | 06:00 | Unidad 1 | 70 | Deiby Arias O | 25011106 | 25011127 | 70.00 | 55 |
| 55 | PH Pirrís | manual | 7.8d | 2017-07-07 | 2017-07-10 | 06:00 | Unidad 2 | 70 | Deiby Arias O | 25011106 | 25011127 | 70.00 | 54 |
| 56 | PH Pirrís | manual | 3.8d | 2017-10-16 | 2017-10-17 | 06:00 | Unidad 1 | 70 | Deiby Arias O | 25011106 | 25011127 | 70.00 | 57 |
| 57 | PH Pirrís | manual | 6.2d | 2017-10-11 | 2017-10-13 | 06:00 | Unidad 2 | 70 | Deiby Arias O | 25011106 | 25011127 | 70.00 | 58 |
| 58 | PT Orotina | manual | 3.6d | 2017-09-18 | 2017-09-19 | 06:00 | Unidad 1 | 4.7 | Glenn Angulo Falla | 88896031 | 20002746 | 4.74 | 59 |
| 59 | PT Orotina | manual | 3.6d | 2017-09-20 | 2017-09-21 | 06:00 | Unidad 2 | 4.7 | Glenn Angulo Falla | 88896031 | 20002746 | 4.74 | 60 |
| 60 | PT Orotina | manual | 15.6d | 2017-11-06 | 2017-11-12 | 06:00 | Unidad 1 | 4.7 | Glenn Angulo Falla | 88896031 | 20002746 | 9.47 | 61 |
| 61 | PT Barranca | manual | 27.6d | 2017-10-02 | 2017-10-13 | 06:00 | Unidad 1 | 18 | Glenn Angulo Falla | 88896031 | 20002746 | 17.89 | 62 |
| 62 | PT Barranca | manual | 27.6d | 2017-10-16 | 2017-10-27 | 06:00 | Unidad 2 | 18 | Glenn Angulo Falla | 88896031 | 20002746 | 17.89 | 63 |
| 63 | PT Garabito | manual | 4.8d | 2017-01-14 | 2017-01-15 | 00:00 | Unidad 1 | 18 | Verny Rojas | 20002810 | 20002860 | 17.70 | 64 |
| 64 | PT Garabito | manual | 7.2d | 2017-01-11 | 2017-01-13 | 00:00 | Unidad 2 | 18 | Verny Rojas | 20002810 | 20002860 | 17.70 | 65 |
| 65 | PT Garabito | manual | 7.2d | 2017-01-13 | 2017-01-15 | 00:00 | Unidad 3 | 18 | Verny Rojas | 20002810 | 20002860 | 17.70 | 66 |
| 66 | PT Garabito | manual | 12d | 2017-01-14 | 2017-01-18 | 00:00 | Unidad 4 | 18 | Verny Rojas | 20002810 | 20002860 | 17.70 | 67 |
| 67 | PT Garabito | manual | 7.2d | 2017-01-13 | 2017-01-15 | 00:00 | Unidad 5 | 18 | Verny Rojas | 20002810 | 20002860 | 17.70 | 68 |
| 68 | PT Garabito | manual | 4.8d | 2017-01-14 | 2017-01-15 | 00:00 | Unidad 6 | 18 | Verny Rojas | 20002810 | 20002860 | 17.70 | 69 |
| 69 | PT Garabito | manual | 4.8d | 2017-01-14 | 2017-01-15 | 00:00 | Unidad 7 | 18 | Verny Rojas | 20002810 | 20002860 | 17.70 | 70 |
| 70 | PT Garabito | manual | 4.8d | 2017-01-14 | 2017-01-15 | 00:00 | Unidad 8 | 18 | Verny Rojas | 20002810 | 20002860 | 17.70 | 71 |

Notes:
- 1: 23:59 / Hora finalizacion: 23:59 / Text10: Mantenimiento Anual (sandblasting y aplicación BELZONA en desfogue)
- 2: 23:59 / Hora finalizacion: 23:59 / Text10: Primer Vaciado Presa Garita
- 3: 23:59 / Hora finalizacion: 23:59 / Text10: Segundo Vaciado Presa Garita
- 4: 23:59 / Hora finalizacion: 23:59 / Text10: Mantenimiento Anual (sandblasting y aplicación BELZONA en desfogue)
- 5: 23:59 / Hora finalizacion: 23:59 / Text10: Primer Vaciado Presa Garita
- 6: 23:59 / Hora finalizacion: 23:59 / Text10: Segundo Vaciado Presa Garita
- 7: 23:59 / Hora finalizacion: 23:59 / Text10: Mantenimiento Intermedio e instalación protecciones respaldo unidades
- 8: 23:59 como se requiere limpieza del embalse con maquinaria se ocupa realizar el trabajo en verano ya que si llueve se inunda la maquinaria / Hora finalizacion: 23:59 / Text10: Primer Vaciado Toma Virilla
- 9: 23:59 / Hora finalizacion: 23:59 / Text10: Segundo Vaciado Toma Virilla
- 10: 23:59 / Hora finalizacion: 23:59 / Text10: Mantenimiento Anual e instalación protecciones respaldo unidades
- 11: 23:59 / Hora finalizacion: 23:59 / Text10: Primer Vaciado Toma Virilla
- 12: 23:59 / Hora finalizacion: 23:59 / Text10: Segundo Vaciado Toma Virilla
- 13: 23:59 / Hora finalizacion: 23:59 / Text10: Mantenimiento Anual y verificar funcionamiento rodete respaldo
- 14: 23:59 / Hora finalizacion: 23:59 / Text10: Mantenimiento anual rutinario y cambio de sello válvula admisión
- 15: 23:59 / Hora finalizacion: 23:59 / Text10: Instalacion de Valvula en lugar de Tapon U1 Toro 1
- 16: 23:59 / Hora finalizacion: 23:59 / Text10: Instalacion de Valvula en lugar de Tapon U1 Toro 1
- 17: 23:59 / Hora finalizacion: 23:59 / Text10: Mantenimiento anual rutinario
- 18: 23:59 / Hora finalizacion: 23:59 / Text10: Mantenimiento anual rutinario
- 19: 23:59 / Hora finalizacion: 23:59 / Text10: Mantenimiento anual rutinario
- 20: 23:59 / Hora finalizacion: 23:59 / Text10: Reserva por instalacion de Tapon en lugar de Valvula U1 Toro 1
- 21: 23:59 / Hora finalizacion: 23:59 / Text10: Reserva por instalacion de Valvula en lugar de Tapon U1 Toro 1
- 22: 23:59 / Hora finalizacion: 23:59 / Text10: Desembalse
- 23: 23:59 / Hora finalizacion: 23:59 / Text10: Mantenimiento anual rutinario
- 24: 23:59 / Hora finalizacion: 23:59 / Text10: Mantenimiento anual rutinario
- 25: 23:59 / Hora finalizacion: 23:59 / Text10: Reserva por instalacion de Tapon en lugar de Valvula U1 Toro 1
- 26: 23:59 / Hora finalizacion: 23:59 / Text10: Reserva por instalacion de Valvula en lugar de Tapon U1 Toro 1
- 27: 23:59 / Hora finalizacion: 23:59 / Text10: Reserva por desembalse Toro 2
- 28: 00:00 / Hora finalizacion: 00:00 / Text10: Mantenimiento anual rutinario
- 29: 00:00 / Hora finalizacion: 00:00 / Text10: Mantenimiento anual rutinario
- 30: 00:00 / Hora finalizacion: 00:00 / Text10: Desembalse 1
- 31: 00:00 / Hora finalizacion: 00:00 / Text10: Desembalse 2
- 32: 16:00 / Hora finalizacion: 16:00 / Text10: Desembalse 3
- 33: 23:59 / Hora finalizacion: 23:59 / Text10: Mantenimiento anual rutinario
- 34: 23:59 / Hora finalizacion: 23:59 / Text10: Mantenimiento anual rutinario
- 35: 00:00 / Hora finalizacion: 00:00 / Text10: Desembalse + Mto anual equipo compartido
- 36: 00:00 / Hora finalizacion: 00:00 / Text10: Limpieza Toma Sarapiquí
- 37: 00:00 / Hora finalizacion: 00:00 / Text10: Pruebas de eficiencia
- 38: 16:00 / Hora finalizacion: 16:00 / Text10: Mantenimiento anual
- 39: 16:00 / Hora finalizacion: 16:00 / Text10: Mantenimiento anual
- 40: 16:00 / Hora finalizacion: 16:00 / Text10: Mantenimiento anual del transformador elevador
- 41: 16:00 / Hora finalizacion: 16:00 / Text10: Mantenimiento anual del transformador elevador
- 42: 15:00 / Hora finalizacion: 15:00 / Text10: Sustitución tubería aire de arranque
- 43: 15:00 / Hora finalizacion: 15:00 / Text10: Sustitución tubería aire de arranque
- 44: 15:00 / Hora finalizacion: 15:00 / Text10: Instalación tanque almacenamiento de agua de enfriamiento de las unidades
- 45: 15:00 / Hora finalizacion: 15:00 / Text10: Instalación tanque almacenamiento de agua de enfriamiento de las unidades
- 46: 15:00 / Hora finalizacion: 15:00 / Text10: Sustitución tanque de compensación de agua
- 47: 17:00 / Hora finalizacion: 17:00 / Text10: Mantenimiento 1500hrs
- 48: 17:00 / Hora finalizacion: 17:00 / Text10: Mantenimiento 1500hrs
- 49: 20:00 / Hora finalizacion: 20:00 / Text10: Mantenimiento trimestral I U/1
- 50: 20:00 / Hora finalizacion: 20:00 / Text10: Mantenimiento trimestral I U/2
- 51: 20:00 Pirris requiere mantenimiento trimestral y no se puede modificar por lo que se acomoda en semana sanata para buscar menor impacto / Hora finalizacion: 20:00 Pirris requiere mantenimiento trimestral y no se puede modificar por lo que se acomoda en semana sanata para buscar menor impacto / Text10: Mantenimiento trimestral II U/1
- 52: 20:00 / Hora finalizacion: 20:00 / Text10: Mantenimiento trimestral II U/2
- 53: 23:59 / Hora finalizacion: 23:59 / Text10: Mantenimiento bi-anual U/1+2
- 54: 23:59 / Hora finalizacion: 23:59 / Text10: Mantenimiento bi-anual U/1
- 55: 23:59 / Hora finalizacion: 23:59 / Text10: Mantenimiento bi-anual U/1+2
- 56: 20:00 / Hora finalizacion: 20:00 / Text10: Mantenimiento trimestral III U/1
- 57: 20:00 / Hora finalizacion: 20:00 / Text10: Mantenimiento trimestral III U/2
- 58: 18:00 / Hora finalizacion: 18:00 / Text10: Realizar pruebas de confiabilidad (boroscopias, deflexiones del cigueñal, vibraciones mecánicas y termografías)
- 59: 18:00 / Hora finalizacion: 18:00 / Text10: Realizar pruebas de confiabilidad (boroscopias, deflexiones del cigueñal, vibraciones mecánicas y termografías)
- 60: 18:00 / Hora finalizacion: 18:00 / Text10: Mantenimiento de Subestación Eléctrica, Radiadores de Unidades y demás Equipos Auxiliares
- 61: 18:00 / Hora finalizacion: 18:00 / Text10: Mantenimiento Unidad Generadora; Realizar inspección de combustión de turbina y revisión de generador
- 62: 18:00 / Hora finalizacion: 18:00 / Text10: Mantenimiento Unidad Generadora; Realizar inspección de combustión de turbina y revisión de generador
- 63: 23:59 / Hora finalizacion: 23:59 / Text10: Interconexión de calderas nuevas
- 64: 23:59 / Hora finalizacion: 23:59 / Text10: Interconexión de calderas nuevas
- 65: 23:59 / Hora finalizacion: 23:59 / Text10: Interconexión de calderas nuevas
- 66: 23:59 / Hora finalizacion: 23:59 / Text10: Interconexión de calderas nuevas
- 67: 23:59 / Hora finalizacion: 23:59 / Text10: Interconexión de calderas nuevas
- 68: 23:59 / Hora finalizacion: 23:59 / Text10: Interconexión de calderas nuevas
- 69: 23:59 / Hora finalizacion: 23:59 / Text10: Interconexión de calderas nuevas
- 70: 23:59 / Hora finalizacion: 23:59 / Text10: Interconexión de calderas nuevas

| ID | Task | Type | Duration | Start | Finish | Hora inicio | Unidad | Consecutivo | Hora finalizacion | Potencia indisponible | Text11 | Text12 | Text13 | Text14 |
| --- | --- | --- | --- | --- | --- | --- | --- | --- | --- | --- | --- | --- | --- | --- |
| 71 | PT Garabito | manual | 4.8d | 2017-01-14 | 2017-01-15 | 00:00 | Unidad 9 | 72 | 23:59 | 18 | Verny Rojas | 20002810 | 20002860 | 17.70 |
| 72 | PT Garabito | manual | 4.8d | 2017-01-14 | 2017-01-15 | 00:00 | Unidad 10 | 73 | 23:59 | 18 | Verny Rojas | 20002810 | 20002860 | 17.70 |
| 73 | PT Garabito | manual | 4.8d | 2017-01-14 | 2017-01-15 | 00:00 | Unidad 11 | 74 | 23:59 | 18 | Verny Rojas | 20002810 | 20002860 | 17.70 |
| 74 | PT Garabito | manual | 6.7d | 2017-01-18 | 2017-01-20 | 00:00 | Unidad 5 | 78 | 00:00 | 18 | Verny Rojas | 20002810 | 20002844 | 17.70 |
| 75 | PT Garabito | manual | 6d | 2017-01-20 | 2017-01-22 | 00:00 | Unidad 6 | 79 | 00:00 | 18 | Verny Rojas | 20002810 | 20002844 | 17.70 |
| 76 | PT Garabito | manual | 4.8d | 2017-01-23 | 2017-01-25 | 00:00 | Unidad 7 | 80 | 00:00 | 18 | Verny Rojas | 20002810 | 20002844 | 17.70 |
| 77 | PT Garabito | manual | 4.8d | 2017-01-25 | 2017-01-27 | 00:00 | Unidad 8 | 81 | 00:00 | 18 | Verny Rojas | 20002810 | 20002844 | 17.70 |
| 78 | PT Garabito | manual | 4.8d | 2017-01-27 | 2017-01-29 | 00:00 | Unidad 9 | 82 | 00:00 | 18 | Verny Rojas | 20002810 | 20002844 | 17.70 |
| 79 | PT Garabito | manual | 4.8d | 2017-01-30 | 2017-02-01 | 00:00 | Unidad 10 | 83 | 00:00 | 18 | Verny Rojas | 20002810 | 20002844 | 17.70 |
| 80 | PT Garabito | manual | 48h | 2017-02-01 | 2017-02-03 | 00:00 | Unidad 11 | 84 | 00:00 | 18 | Verny Rojas | 20002810 | 20002844 | 17.70 |
| 81 | PT Garabito | manual | 45.6d | 2017-06-05 | 2017-06-23 | 00:00 | Unidad 11 | 85 | 23:59 | 18 | Verny Rojas | 20002810 | 20002844 | 17.70 |
| 82 | PT Garabito | manual | 38.4d | 2017-07-03 | 2017-07-18 | 00:00 | Unidad 2 | 86 | 23:59 | 18 | Verny Rojas | 20002810 | 20002844 | 17.70 |
| 83 | PT Garabito | manual | 38.4d | 2017-07-24 | 2017-08-08 | 00:00 | Unidad 3 | 87 | 23:59 | 18 | Verny Rojas | 20002810 | 20002844 | 17.70 |
| 84 | PT Garabito | manual | 74.4d | 2017-07-31 | 2017-08-31 | 00:00 | Unidad 4 | 88 | 00:00 | 18 | Verny Rojas | 20002810 | 20002844 | 17.70 |
| 85 | PT Garabito | manual | 31.2d | 2017-09-04 | 2017-09-16 | 00:00 | Unidad 5 | 89 | 23:59 | 18 | Verny Rojas | 20002810 | 20002844 | 17.70 |
| 86 | PT Garabito | manual | 31.2d | 2017-09-25 | 2017-10-07 | 00:00 | Unidad 1 | 90 | 23:59 | 18 | Verny Rojas | 20002810 | 20002844 | 17.70 |
| 87 | PT Garabito | manual | 31.2d | 2017-09-25 | 2017-10-07 | 00:00 | Unidad 2 | 91 | 23:59 | 18 | Verny Rojas | 20002810 | 20002844 | 17.70 |
| 88 | PT Garabito | manual | 31.2d | 2017-09-25 | 2017-10-07 | 00:00 | Unidad 3 | 92 | 23:59 | 18 | Verny Rojas | 20002810 | 20002844 | 17.70 |
| 89 | PT Garabito | manual | 31.2d | 2017-09-25 | 2017-10-07 | 00:00 | Unidad 4 | 93 | 23:59 | 18 | Verny Rojas | 20002810 | 20002844 | 17.70 |
| 90 | PT Garabito | manual | 31.2d | 2017-09-25 | 2017-10-07 | 00:00 | Unidad 5 | 94 | 23:59 | 18 | Verny Rojas | 20002810 | 20002844 | 17.70 |
| 91 | PT Garabito | manual | 31.2d | 2017-09-25 | 2017-10-07 | 00:00 | Unidad 6 | 95 | 23:59 | 18 | Verny Rojas | 20002810 | 20002844 | 17.70 |
| 92 | PT Garabito | manual | 31.2d | 2017-10-23 | 2017-11-04 | 00:00 | Unidad 7 | 96 | 23:59 | 18 | Verny Rojas | 20002810 | 20002844 | 17.70 |
| 93 | PT Garabito | manual | 31.2d | 2017-10-23 | 2017-11-04 | 00:00 | Unidad 8 | 97 | 23:59 | 18 | Verny Rojas | 20002810 | 20002844 | 17.70 |
| 94 | PT Garabito | manual | 31.2d | 2017-10-23 | 2017-11-04 | 00:00 | Unidad 9 | 98 | 23:59 | 18 | Verny Rojas | 20002810 | 20002844 | 17.70 |
| 95 | PT Garabito | manual | 31.2d | 2017-10-23 | 2017-11-04 | 00:00 | Unidad 10 | 99 | 23:59 | 18 | Verny Rojas | 20002810 | 20002844 | 17.70 |
| 96 | PT Garabito | manual | 31.2d | 2017-10-23 | 2017-11-04 | 00:00 | Unidad 11 | 100 | 23:59 | 18 | Verny Rojas | 20002810 | 20002844 | 17.70 |
| 97 | PT Garabito | manual | 31.2d | 2017-11-20 | 2017-12-02 | 00:00 | Unidad 9 | 102 | 23:59 | 18 | Verny Rojas | 20002810 | 20002844 | 17.70 |
| 98 | PT Garabito | manual | 31.2d | 2017-12-04 | 2017-12-16 | 00:00 | Unidad 10 | 103 | 23:59 | 18 | Verny Rojas | 20002810 | 20002844 | 17.70 |
| 99 | PH Angostura | manual | 296.2d | 2017-07-24 | 2017-11-24 | 07:00 | Unidad 1 | 104 | 17:00 | 60 | Ronny Bonilla Zúñiga | 2003950 | 2003950 | 60 |
| 100 | PH Angostura | manual | 29.8d | 2017-05-29 | 2017-06-10 | 07:00 | Unidad 2 | 105 | 17:00 | 60 | Ronny Bonilla Zúñiga | 2003950 | 2003950 | 60 |
| 101 | PH Angostura | manual | 29.8d | 2017-06-12 | 2017-06-24 | 07:00 | Unidad 3 | 106 | 17:00 | 60 | Ronny Bonilla Zúñiga | 2003950 | 2003950 | 60 |
| 102 | PH Angostura | manual | 14.6d | 2017-10-03 | 2017-10-10 | 22:00 | Unidad 1 | 107 | 00:00 | 60 | Ronny Bonilla Zúñiga | 2003950 | 2003950 | 180 |
| 103 | PH Cachí | manual | 46.7d | 2017-06-26 | 2017-07-15 | 06:00 | Unidad 1 | 108 | 17:00 | 40 | Cristián Dotti Dondi | 20003801 | 20003801 | 35 |
| 104 | PH Cachí | manual | 300.6d | 2017-02-06 | 2017-06-11 | 06:00 | Unidad 2 | 109 | 12:00 | 40 | Cristián Dotti Dondi | 20003801 | 20003801 | 35 |
| 105 | PH Cachí | manual | 46.7d | 2017-06-26 | 2017-07-15 | 06:00 | Unidad 3 | 110 | 17:00 | 40 | Cristián Dotti Dondi | 20003801 | 20003801 | 40 |
| 106 | PH Cachí | manual | 46.2d | 2017-11-13 | 2017-12-02 | 06:00 | Unidad 4 | 111 | 12:00 | 40 | Cristián Dotti Dondi | 20003801 | 20003801 | 40 |
| 107 | PT Moín | manual | 1042.1d | 2017-10-23 | 2018-12-31 | 07:00 | Unidad 5 | 112 | 12:00 | 33 | Ricardo Castillo Álvarez | 20002572 | 20002572 | 35 |
| 108 | PT Moín | manual | 46.1d | 2017-06-05 | 2017-06-24 | 07:00 | Unidad 6 | 113 | 12:00 | 33 | Ricardo Castillo Álvarez | 20002572 | 20002572 | 35 |
| 109 | PT Moín | manual | 44.2d | 2017-06-26 | 2017-07-14 | 07:00 | Unidad 7 | 114 | 12:00 | 33 | Ricardo Castillo Álvarez | 20002572 | 20002572 | 35 |
| 110 | PT Moín | manual | 1042.1d | 2017-10-23 | 2018-12-31 | 07:00 | Unidad 8 | 115 | 12:00 | 33 | Ricardo Castillo Álvarez | 20002572 | 20002572 | 35 |
| 111 | PT Moín | manual | 44.9d | 2017-08-14 | 2017-09-01 | 07:00 | Unidad 9 | 116 | 23:59 | 33 | Ricardo Castillo Álvarez | 20002572 | 20002572 | 35 |
| 112 | PT Moín | manual | 44.9d | 2017-09-04 | 2017-09-22 | 07:00 | Unidad 10 | 117 | 23:59 | 33 | Ricardo Castillo Álvarez | 20002572 | 20002572 | 35 |
| 113 | PH Reventazón | manual | 78d | 2017-07-31 | 2017-09-02 | 12:00 | Unidad 1 | 118 | 12:00 | 75 | Eduardo Alvarado Soto | 27997299 | 27997299 | 72 |
| 114 | PH Reventazón | manual | 780h | 2017-07-31 | 2017-09-02 | 12:00 | Unidad 2 | 119 | 12:00 | 75 | Eduardo Alvarado Soto | 27997299 | 27997299 | 72 |
| 115 | PH Reventazón | manual | 780h | 2017-07-31 | 2017-09-02 | 12:00 | Unidad 3 | 120 | 12:00 | 75 | Eduardo Alvarado Soto | 27997299 | 27997299 | 72 |
| 116 | PH Reventazón | manual | 780h | 2017-07-31 | 2017-09-02 | 12:00 | Unidad 4 | 121 | 12:00 | 75 | Eduardo Alvarado Soto | 27997299 | 27997299 | 72 |
| 117 | PH Reventazón | manual | 12.5d | 2017-09-04 | 2017-09-09 | 07:00 | Unidad 5 | 122 | 12:00 | 14 | Eduardo Alvarado Soto | 27997299 | 27997299 | 14 |
| 118 | PH Río Macho | manual | 148.8d | 2017-10-30 | 2017-12-31 | 00:00 | Unidad 1 | 123 | 00:00 | 18 | Santiago Quirós Vargas | 20003850 | 20003850 | 144 |
| 119 | PH Río Macho | manual | 31.7d | 2017-08-14 | 2017-08-27 | 07:00 | Unidad 5 | 124 | 12:00 | 36 | Santiago Quirós Vargas | 20003850 | 20003850 | 36 |
| 120 | PE Tejona | manual | 44.4d | 2017-05-08 | 2017-05-26 | 06:00 | Unidad 1 | 125 | 18:00 |  | Pablo Palma | 20003254 | 20003254 | 0.66 |
| 121 | PE Tejona | manual | 44.4d | 2017-05-29 | 2017-06-16 | 06:00 | Unidad 2 | 126 | 18:00 |  | Pablo Palma | 20003254 | 20003254 | 0.66 |
| 122 | PG Pailas | manual | 6d | 2017-06-02 | 2017-06-04 | 06:00 | Unidad 1 | 127 | 18:00 | 17 | Roy Canton | 20003192 | 20003192 | 21 |
| 123 | PG Pailas | manual | 6d | 2017-06-02 | 2017-06-04 | 06:00 | Unidad 2 | 128 | 18:00 | 17 | Roy Canton | 20003192 | 20003192 | 21 |
| 124 | PH Sandillal | manual | 64.1d | 2017-06-12 | 2017-07-08 | 06:00 | Unidad 2 | 129 | 23:00 | 16 | Jose William Cordero | 20003180 | 20003180 | 15.98 |
| 125 | PH Sandillal | manual | 47.3d | 2017-06-12 | 2017-07-01 | 06:00 | Unidad 1 | 130 | 23:00 | 16 | Jose William Cordero | 20003180 | 20003180 | 15.98 |
| 126 | PG Boca de Pozo | manual | 11.4d | 2017-06-19 | 2017-06-23 | 06:00 | Unidad 1 | 131 | 23:00 |  | Lenin Cespedes | 20003193 | 20003193 | 4.99 |
| 127 | PG Miravalles III | manual | 59.5d | 2017-07-03 | 2017-07-28 | 06:00 | Unidad 1 | 132 | 23:00 | 27 | Lenin Cespedes | 20003193 | 20003193 | 29.45 |
| 128 | PH Arenal | manual | 49.7d | 2017-12-10 | 2017-12-30 | 06:00 | Unidad 3 | 133 | 23:00 | 58 | Jose William Cordero | 20003180 | 20003180 | 52.4 |
| 129 | PH Arenal | manual | 47.3d | 2017-10-10 | 2017-10-29 | 06:00 | Unidad 1 | 134 | 23:00 | 58 | Jose William Cordero | 20003180 | 20003180 | 52.4 |
| 130 | PG Miravalles | manual | 16.1d | 2017-09-04 | 2017-09-10 | 06:00 | Unidad 2 | 135 | 23:00 | 42 | Lenin Cespedes | 20003193 | 20003193 | 10.5 |
| 131 | PE Tejona | manual | 44.4d | 2017-09-18 | 2017-10-06 | 06:00 | Unidad 1 | 136 | 18:00 |  | Pablo Palma | 20003254 | 20003254 | 0.66 |
| 132 | PE Tejona | manual | 44.4d | 2017-10-09 | 2017-10-27 | 06:00 | Unidad 2 | 137 | 18:00 |  | Pablo Palma | 20003254 | 20003254 | 0.66 |
| 133 | PH Dengo | manual | 36h | 2017-09-16 | 2017-09-17 | 06:00 | Unidad 3 | 138 | 18:00 | 58 | Jose William Cordero | 20003180 | 20003180 | 58 |
| 134 | PH Dengo | manual | 36h | 2017-09-16 | 2017-09-17 | 06:00 | Unidad 2 | 139 | 18:00 | 58 | Jose William Cordero | 20003180 | 20003180 | 58 |
| 135 | PH Dengo | manual | 35.3d | 2017-09-16 | 2017-09-30 | 06:00 | Unidad 1 | 140 | 23:00 | 58 | Jose William Cordero | 20003180 | 20003180 | 58 |
| 136 | PH Dengo | manual | 36h | 2017-09-23 | 2017-09-24 | 06:00 | Unidad 2 | 141 | 18:00 | 58 | Jose William Cordero | 20003180 | 20003180 | 58 |
| 137 | PH Dengo | manual | 3.6d | 2017-09-23 | 2017-09-24 | 06:00 | Unidad 3 | 142 | 18:00 | 58 | Jose William Cordero | 20003180 | 20003180 | 58 |
| 138 | PG Pailas | manual | 16.1d | 2017-09-18 | 2017-09-24 | 06:00 | Unidad 1 | 143 | 23:00 | 17 | Roy Canton | 20003192 | 20003192 | 21 |
| 139 | PG Pailas | manual | 16.1d | 2017-09-20 | 2017-09-26 | 06:00 | Unidad 2 | 144 | 23:00 | 17 | Roy Canton | 20003192 | 20003192 | 21 |
| 140 | PH Cachí | manual | 50h | 2017-10-03 | 2017-10-06 | 22:00 | Unidad 1 |  | 00:00 | 40 | Ronny Bonilla Zúñiga | 2003950 | 2003950 | 180 |

Notes:
- 71: 23:59 / Text10: Interconexión de calderas nuevas
- 72: 23:59 / Text10: Interconexión de calderas nuevas
- 73: 23:59 / Text10: Interconexión de calderas nuevas
- 74: 00:00 / Text10: Mantenimiento preventivo módulo purgas y prelubricación
- 75: 00:00 / Text10: Mantenimiento preventivo módulo purgas y prelubricación
- 76: 00:00 / Text10: Mantenimiento preventivo módulo purgas y prelubricación
- 77: 00:00 / Text10: Mantenimiento preventivo módulo purgas y prelubricación
- 78: 00:00 / Text10: Mantenimiento preventivo módulo purgas y prelubricación
- 79: 00:00 / Text10: Mantenimiento preventivo módulo purgas y prelubricación
- 80: 00:00 / Text10: Mantenimiento preventivo módulo purgas y prelubricación
- 81: 23:59 / Text10: Mantenimiento anual y mantenimiento 15000
- 82: 23:59 / Text10: Mantenimiento 3000-4000 y Mantenimiento anual
- 83: 23:59 / Text10: Mantenimiento 3000-4000 y Mantenimiento anual
- 84: 00:00 / Text10: Mantenimiento 5000-6000 y Mantenimiento anual. Mantenimiento Mayor Caldera
- 85: 23:59 / Text10: Mantenimiento anual
- 86: 23:59 / Text10: Paro de casa máquinas 1
- 87: 23:59 / Text10: Paro de casa máquinas 1
- 88: 23:59 / Text10: Paro de casa máquinas 1
- 89: 23:59 / Text10: Paro de casa máquinas 1
- 90: 23:59 / Text10: Paro de casa máquinas 1
- 91: 23:59 / Text10: Paro de casa máquinas 1 y Mantenimiento anual
- 92: 23:59 / Text10: Paro de casa de maquinas 2 Mantenimiento anual
- 93: 23:59 / Text10: Paro de casa de maquinas 2
- 94: 23:59 / Text10: Paro de casa de maquinas 2
- 95: 23:59 / Text10: Paro de casa de maquinas 2
- 96: 23:59 / Text10: Paro de casa de maquinas 2
- 97: 23:59 / Text10: Mantenimiento anual
- 98: 23:59 / Text10: Mantenimiento anual
- 99: 17:00 / Text10: Rebobinado Estator
- 100: 17:00 / Text10: Manto Anual
- 101: 17:00 / Text10: Manto Anual
- 102: 00:00 / Text10: Desembalse Angostura
- 103: 17:00 / Text10: Manto Anual
- 104: 12:00 / Text10: Mantenimiento Mayor
- 105: 17:00 / Text10: Manto Anual
- 106: 12:00 / Text10: Manto Anual
- 107: 12:00 / Text10: Manto Mayor
- 108: 12:00 / Text10: Manto Anual
- 109: 12:00 / Text10: Manto Anual
- 110: 12:00 / Text10: Manto Mayor
- 111: 23:59 / Text10: Manto Anual
- 112: 23:59 / Text10: Manto Anual
- 113: 12:00 / Text10: Manto Anual
- 114: 12:00 / Text10: Manto Anual
- 115: 12:00 / Text10: Manto Anual
- 116: 12:00 / Text10: Manto Anual
- 117: 12:00 / Text10: Manto Anual
- 118: 00:00 / Text10: Reparación de Tubería y Galería
- 119: 12:00 / Text10: Manto Anual
- 120: 18:00 / Text10: Mant. Semianual aerogeneradores Montecristo 1 (1 maquina/día)
- 121: 18:00 / Text10: Mant. Semianual aerogeneradores Montecristo 2 (1 maquina/día)
- 122: 18:00 / Text10: Mant. Semianual
- 123: 18:00 / Text10: Mant. Semianual
- 124: 23:00 / Text10: Mant. Mayor Anual
- 125: 23:00 / Text10: Mant. Mayor Anual
- 126: 23:00 / Text10: Mant. Mayor Anual
- 127: 23:00 / Text10: Overhaul Miravalles III/Cambio Estator/Cambio rellenos TE
- 128: 23:00 / Text10: Mant. Mayor Anual
- 129: 23:00 / Text10: Mant. Mayor Anual
- 130: 23:00 / Text10: Overhaul Miravalles V
- 131: 18:00 / Text10: Mant. anual aerogeneradores Montecristo 1 (1 maquina/día)
- 132: 18:00 / Text10: Mant. anual aerogeneradores Montecristo 2 (1 maquina/día)
- 133: 18:00 / Text10: Mant. Menor Proy. Transferencia Servicio Propio/Baco Baterías
- 134: 18:00 / Text10: Mant. Menor Proy. Transferencia Servicio Propio/Baco Baterías
- 135: 23:00 / Text10: Mant. Mayor Anual
- 136: 18:00 / Text10: Mant. Menor Proy. Transferencia Servicio Propio/Baco Baterías
- 137: 18:00 / Text10: Mant. Menor Proy. Transferencia Servicio Propio/Baco Baterías
- 138: 23:00 / Text10: Mantenimiento Anual
- 139: 23:00 / Text10: Mantenimiento Anual
- 140: 00:00 / Text10: Desembalse Angostura

| ID | Task | Type | Duration | Start | Finish | Hora inicio | Unidad | Consecutivo | Hora finalizacion | Potencia indisponible | Text11 | Text12 | Text13 | Text14 |
| --- | --- | --- | --- | --- | --- | --- | --- | --- | --- | --- | --- | --- | --- | --- |
| 141 | PH Arenal | manual | 47.3d | 2017-10-30 | 2017-11-18 | 06:00 | Unidad 2 | 145 | 23:00 | 58 | Jose William Cordero | 20003180 | 20003180 | 52.4 |
| 142 | PG Miravalles | manual | 16.1d | 2017-11-06 | 2017-11-12 | 06:00 | Unidad 1 | 146 | 23:00 | 42 | Lenin Cespedes | 20003193 | 20003193 | 55 |
| 143 | PH Dengo | manual | 49.7d | 2017-11-19 | 2017-12-09 | 06:00 | Unidad 3 | 147 | 23:00 | 58 | Jose William Cordero | 20003180 | 20003180 | 58 |
| 144 | PH Sandillal | manual | 8.9d | 2017-11-30 | 2017-12-03 | 06:00 | Unidad 1 | 148 | 23:00 | 16 | Jose William Cordero | 20003180 | 20003180 | 15.98 |
| 145 | PH Sandillal | manual | 8.9d | 2017-11-30 | 2017-12-03 | 06:00 | Unidad 2 | 149 | 23:00 | 16 | Jose William Cordero | 20003180 | 20003180 | 15.98 |
| 146 | PG Miravalles V | manual | 42.5d | 2017-12-04 | 2017-12-21 | 06:00 | Unidad 1 | 150 | 23:00 |  | Lenin Cespedes | 20003193 | 20003193 | 55 |
| 147 | PH Dengo | manual | 281h | 2017-07-17 | 2017-07-28 | 06:00 | Unidad 2 | 151 | 23:00 | 58 | Jose William Cordero | 20003180 | 20003180 | 58 |
| 148 | PS Miravalles | manual | 0.4d | 2017-01-26 | 2017-01-26 | 06:00 | Unidad 1 | 152 | 10:00 |  | Lenin Cespedes | 20003193 | 20003193 |  |
| 149 | PS Miravalles | manual | 0.4d | 2017-08-23 | 2017-08-23 | 06:00 | Unidad 1 | 153 | 10:00 |  | Lenin Cespedes | 20003193 | 20003193 |  |
| 150 | PS Miravalles | manual | 3.6d | 2017-12-13 | 2017-12-14 | 06:00 | Unidad 1 | 154 | 18:00 |  | Lenin Cespedes | 20003193 | 20003193 |  |
| 151 | PH Cariblanco | manual | 24h | 2017-11-17 | 2017-11-18 | 00:00 | Unidad 2 |  | 00:00 | 41 | Javier Chacón S. | 20003725 | 88899717 | 82.00 |
| 152 | PH Peñas Blancas | manual | 80h | 2017-11-16 | 2017-11-19 | 08:00 | Unidad 2 |  | 16:00 | 18 | Rolando Solís Durán | 20003751 | 88249276 |  |
| 153 | PT Orotina | manual | 156h | 2017-11-06 | 2017-11-12 | 06:00 | Unidad 2 |  | 18:00 | 4.7 | Glenn Angulo Falla | 88896031 | 20002746 |  |
| 154 | PH Río Macho | manual | 1488h | 2017-10-30 | 2017-12-31 | 00:00 | Unidad 2 |  | 00:00 | 18 | Santiago Quirós Vargas | 20003850 | 20003850 |  |
| 155 | PH Río Macho | manual | 1488h | 2017-10-30 | 2017-12-31 | 00:00 | Unidad 3 |  | 00:00 | 36 | Santiago Quirós Vargas | 20003850 | 20003850 |  |
| 156 | PH Río Macho | manual | 1488h | 2017-10-30 | 2017-12-31 | 00:00 | Unidad 4 |  | 00:00 | 36 | Santiago Quirós Vargas | 20003850 | 20003850 |  |
| 157 | PH Río Macho | manual | 1488h | 2017-10-30 | 2017-12-31 | 00:00 | Unidad 5 |  | 00:00 | 36 | Santiago Quirós Vargas | 20003850 | 20003850 |  |
| 158 | PH Toro III | manual | 88.98h | 2017-10-27 | 2017-10-30 | 07:00 | Unidad 1 |  | 23:59 | 24 | J. Manuel Rodríguez | 20002305 | 89223534 |  |
| 159 | PH Toro III | manual | 88.98h | 2017-10-27 | 2017-10-30 | 07:00 | Unidad 2 |  | 23:59 | 24 | J. Manuel Rodríguez | 20002305 | 89223534 |  |
| 160 | PH Toro II | manual | 88.98h | 2017-10-27 | 2017-10-30 | 07:00 | Unidad 2 |  | 23:59 | 33 | Luis Alfredo Mora | 20003638 | 87065058 |  |
| 161 | PH Peñas Blancas | manual | 72h | 2017-10-19 | 2017-10-22 | 00:00 | Unidad 2 |  | 00:00 | 18 | Rolando Solís Durán | 20003751 | 88249276 |  |
| 162 | PH Cachí | manual | 50h | 2017-10-03 | 2017-10-06 | 22:00 | Unidad 2 |  | 00:00 | 40 | Ronny Bonilla Zúñiga | 2003950 | 2003950 |  |
| 163 | PH Cachí | manual | 50h | 2017-10-03 | 2017-10-06 | 22:00 | unidad 3 |  | 00:00 | 40 | Ronny Bonilla Zúñiga | 2003950 | 2003950 |  |
| 164 | PH Cachí | manual | 50h | 2017-10-03 | 2017-10-06 | 22:00 | Unidad 4 |  | 00:00 | 40 | Ronny Bonilla Zúñiga | 2003950 | 2003950 |  |
| 165 | PH Angostura | manual | 146h | 2017-10-03 | 2017-10-10 | 22:00 | Unidad 2 |  | 00:00 | 60 | Ronny Bonilla Zúñiga | 2003950 | 2003950 |  |
| 166 | PH Angostura | manual | 146h | 2017-10-03 | 2017-10-10 | 22:00 | Unidad 3 |  | 00:00 | 60 | Ronny Bonilla Zúñiga | 2003950 | 2003950 |  |
| 167 | PH Cariblanco | manual | 48h | 2017-09-29 | 2017-10-01 | 00:00 | Unidad 2 |  | 00:00 | 41 | Javier Chacón S. | 20003725 | 88899717 |  |
| 168 | PH Peñas Blancas | manual | 72h | 2017-09-07 | 2017-09-10 | 00:00 | Unidad 2 |  | 00:00 | 18 | Rolando Solís Durán | 20003751 | 88249276 |  |
| 169 | PH Toro III | manual | 74.98h | 2017-06-08 | 2017-06-11 | 21:00 | Unidad 2 |  | 23:59 | 24 | J. Manuel Rodríguez | 20002305 | 89223534 |  |
| 170 | PH Toro II | manual | 74.98h | 2017-06-08 | 2017-06-11 | 21:00 | Unidad 2 |  | 23:59 | 33 | Luis Alfredo Mora | 20003638 | 87065058 |  |
| 171 | PH Toro III | manual | 74.98h | 2017-05-18 | 2017-05-21 | 21:00 | Unidad 2 |  | 23:59 | 24 | Luis Alfredo Mora | 20003638 | 87065058 |  |
| 172 | PH Toro II | manual | 74.98h | 2017-05-18 | 2017-05-21 | 21:00 | Unidad 2 |  | 23:59 | 33 | Luis Alfredo Mora | 20003638 | 87065058 |  |

Notes:
- 141: 23:00 / Text10: Mantenimiento Anual
- 142: 23:00 / Text10: Mantenimiento Anual
- 143: 23:00 / Text10: Mantenimiento Anual
- 144: 23:00 / Text10: Desembalse
- 145: 23:00 / Text10: Desembalse
- 146: 23:00 / Text10: Mantenimiento Anual
- 147: 23:00 / Text10: Mantenimiento Anual
- 148: 10:00 / Text10: Mantenimiento Menor
- 149: 10:00 / Text10: Mantenimiento Menor
- 150: 18:00 / Text10: Mantenimiento Anual
- 151: Text10: Desembalse + Mto anual equipo compartido
- 152: Text10: Desembalse 3
- 153: Text10: Mantenimiento de Subestación Eléctrica, Radiadores de Unidades y demás Equipos Auxiliares
- 154: Text10: Reparación de Tubería y Galería
- 155: Text10: Reparación de Tubería y Galería
- 156: Text10: Reparación de Tubería y Galería
- 157: Text10: Reparación de Tubería y Galería
- 158: Text10: Reserva por desembalse Toro 2
- 159: Text10: Reserva por desembalse Toro 2
- 160: Text10: Desembalse
- 161: Text10: Desembalse 2
- 162: Text10: Desembalse Angostura
- 163: Text10: Desembalse Angostura
- 164: Text10: Desembalse Angostura
- 165: Text10: Desembalse Angostura
- 166: Text10: Desembalse Angostura
- 167: Text10: Limpieza Toma Sarapiquí
- 168: Text10: Desembalse 1
- 169: Text10: Reserva por instalacion de Valvula en lugar de Tapon U1 Toro 1
- 170: Text10: Reserva por instalacion de Valvula en lugar de Tapon U1 Toro 1
- 171: Text10: Reserva por instalacion de Tapon en lugar de Valvula U1 Toro 1
- 172: Text10: Reserva por instalacion de Tapon en lugar de Valvula U1 Toro 1
